# 4.0 Cronograma de Obra Los Girasoles

Schedule from MS Project, 2026-05-29 to 2026-08-20.

## Calendars

- Estándar: Mon-Fri 09:00-13:00, 15:00-19:00; Sat-Sun off.

## Resources

| Resource | Unit | Rate |
| --- | --- | --- |
| Aceite quemado | gal | 0.6 |
| Acero de refuerzo fy=4200kg/cm2 | kg | 1.35 |
| Agua en m3 | m3 | 1.05 |
| Alambre galvanizado # 18 | kg | 2.36 |
| alfajias 0.04*0.04*2.40 m | u | 1.5 |
| ángulo 2"*3 mm (marco 2 soldado) | u | 21.45 |
| Arena | m3 | 9.78 |
| Caña Guadua | m. | 0.37 |
| Cemento Portland | kg | 0.17 |
| Clavos 2 1/2" | kg | 1.7 |
| Encofrado para pozos hormigón | m. | 3 |
| Estacas (30 cm) | u | 0.35 |
| lastre | m3 | 5.75 |
| Lubricante | Lt | 1.1 |
| Piedra bola | m3 | 10.35 |
| Pintura anticorrosiva | gal | 18.46 |
| Pintura esmalte | gal | 18.25 |
| Ripio (3/4") - material triturado | m3 | 13.8 |
| Sub base clase 3 | m3 | 3.45 |
| Tabla de encofrado 0.30*2.40 m | u | 3.5 |
| tapa redonda HD 600mm | u | 261.33 |
| tiras (2.4x0.025x0.025) - Metros | m. | 0.37 |
| tiras madera e=7 cm | m. | 0.47 |
| tubería PVC para alcantarillado di=160mm | m. | 6.88 |
| tubería PVC para alcantarillado di=200mm | m. | 11.18 |
| Albañil |  | 4.39 |
| Ayudante de Albañil |  | 4.34 |
| Cadenero |  | 4.39 |
| Chofer profesional de tanquero |  | 6.38 |
| Chofer profesional de volqueta |  | 6.38 |
| Encofrador o carpintero de ribera |  | 4.39 |
| Maestro mayor en ejecucion de obras civiles |  | 4.87 |
| OPERADOR cargadora frontal |  | 4.87 |
| OPERADOR de tractor de ruedas (barredora, cargadora, rodillo remolcado, franjeadora) |  | 4.64 |
| OPERADOR motoniveladora |  | 4.87 |
| OPERADOR Retroexcavadora |  | 4.87 |
| Peón |  | 4.34 |
| TOPOGRAFO (En Construcción) |  | 4.87 |
| Cargadora Frontal |  | 55 |
| Concretera 1 Saco |  | 6.5 |
| Estación Total |  | 7.5 |
| Herramienta menor |  | 1 |
| Motoniveladora |  | 65 |
| Nivel Laser |  | 1.5 |
| Retroexcavadora (de llanta) |  | 35 |
| Rodillo Vibratorio |  | 45 |
| Tanquero 12m3 |  | 30 |
| Vibrador |  | 3.5 |
| Vibro compactador(de plancha) |  | 4.25 |
| Volqueta 12m3 |  | 35 |
| Transporte |  |  |

## Schedule

| ID | Task | Type | Duration | Start | Finish | Predecessors |
| --- | --- | --- | --- | --- | --- | --- |
| 1 | PROYECTO ALCANTARILLDO SANITARIO GIRASOLES | manual | 60d | 2026-05-29 | 2026-08-20 |  |
| 2 | Replanteo y nivelación para redes hidrosanitarias. | manual | 3d | 2026-05-29 | 2026-06-02 |  |
| 3 | Base de H.S 0.90x0.90m e=10cm para caja de revisión. | manual | 3d | 2026-06-02 | 2026-06-04 | 12 |
| 4 | Caja de revisión H.S 0.60x0.60 (el cuerpo). | manual | 10d | 2026-06-05 | 2026-06-18 | 3 |
| 5 | Tapa H.A f`c=180 para caja de revisión 0.60x0.60m. | manual | 5d | 2026-06-20 | 2026-06-25 | 4 |
| 6 | Base H.C. del pozo de revisión d=1.50m e=0.30m. | manual | 1d | 2026-06-05 | 2026-06-05 | 12 |
| 7 | Losa de Tapa HA para pozo revisión e=0.20m d=1.40m. | manual | 3d | 2026-06-20 | 2026-06-23 | 10 |
| 8 | Sum/Ins/Tra Tapa Redonda HD 600mm. | manual | 1d | 2026-06-26 | 2026-06-26 | 7 |
| 9 | Sum/Ins/Tra Estribos de pozo de revisión d=16mm. | manual | 2d | 2026-06-23 | 2026-06-24 | 11 |
| 10 | Pozo de Revisión H.S f`c=210kg/cm2 h=0-2m di=1m (el cuerpo). | manual | 3d | 2026-06-17 | 2026-06-19 | 6 |
| 11 | Pozo de Revisión H.S f`c=210kg/cm2 h=2-4m di=1m (el cuerpo). | manual | 1d | 2026-06-20 | 2026-06-20 | 10 |
| 12 | Excavación de suelo natural <2 m (a máquina). | manual | 10d | 2026-06-02 | 2026-06-15 | 2 |
| 13 | Excavación de suelo natural <2m (manual). | manual | 12d | 2026-06-14 | 2026-06-29 | 2 |
| 14 | Excavación de suelo natural 2 a 4 m (a máquina). | manual | 3d | 2026-06-17 | 2026-06-19 | 12 |
| 15 | Sum/Ins/Tra Tubería PVC para alcantarillado dn=220mm. | manual | 4d | 2026-06-29 | 2026-07-02 | 17 |
| 16 | Sum/Ins/Tra Tubería PVC para alcantarillado dn=175mm. | manual | 5d | 2026-06-26 | 2026-07-02 | 17 |
| 17 | Rasanteo y preparación zanja (inc. Cama de arena). | manual | 3d | 2026-06-20 | 2026-06-23 | 12 |
| 18 | Relleno compactado con material de excavación. | manual | 3d | 2026-07-05 | 2026-07-07 | 16 |
| 19 | Desalojo a máquina (dist= 5 km). | manual | 1d | 2026-07-23 | 2026-07-24 | 12 |
| 20 | Relleno compactado con material lastre. | manual | 2d | 2026-07-11 | 2026-07-13 | 18 |
| 21 | Sub-base clase 3 tendido y compactado (maquina). | manual | 2d | 2026-07-14 | 2026-07-15 | 20 |
| 22 | Rotura y reposición de acera e=7 cm f`c=180 kg/cm2. | manual | 20d | 2026-07-23 | 2026-08-19 | 2 |
